# 2-1

How a schedule from MS Project changed from version to version. A marks actual dates.

## Version 1 (saved 2023-10-20, file GANTTPrevisionel.mpp)

| ID | WBS | Task | Duration | Start | Finish | Predecessors | Total float |
| --- | --- | --- | --- | --- | --- | --- | --- |
| 1 | 1 | **Étude de courbes de fréquence cardiaque** | 733h | 2023-09-15 | 2026-01-14 |  |  |
| 2 | 1.1 | **1 - Management de projet** | 224h | 2023-09-15 | 2024-05-31 |  |  |
| 3 | 1.1.1 | **1.1 - Recueil de besoins** | 49h | 2023-09-15 | 2023-11-08 |  |  |
| 4 |  | 1.1.1 - Présentation general du projet | 5h | 2023-09-15 | 2023-09-20 | 10 |  |
| 5 |  | 1.1.2 - Compte rendu 1 | 9h | 2023-09-20 | 2023-09-29 | 4, 9 |  |
| 6 |  | 1.1.3 - Compte rendu 2 | 4h | 2023-10-04 | 2023-10-06 | 7 |  |
| 7 |  | 1.1.4 - Backlog (users stories) | 0h | 2023-10-06 | 2023-10-06 | 5 |  |
| 8 | 1.1.1.5 | **1.1.5 - Rendez vous** | 2h | 2023-09-15 | 2023-09-15 |  |  |
| 9 |  | 1.1.5.1 - Avec le tuteur | 1h | 2023-09-15 | 2023-09-15 |  |  |
| 10 |  | 1.1.5.2 - Avec le client | 1h | 2023-09-15 | 2023-09-15 |  |  |
| 11 | 1.1.2 | **1.2 - Organisation du travail en équipe** | 22h | 2023-09-15 | 2023-10-09 |  |  |
| 12 |  | 1.2.1 - Mise en place du kanban | 2h | 2023-09-15 | 2023-09-15 |  |  |
| 13 |  | 1.2.2 - Mise en place du codefirst | 15h | 2023-09-15 | 2023-10-02 |  |  |
| 14 |  | 1.2.3 - Mise en place du notion | 3h | 2023-09-15 | 2023-09-18 |  |  |
| 15 |  | 1.2.4 - Mise en place du discord | 2h | 2023-09-15 | 2023-09-15 |  |  |
| 16 | 1.1.3 | **1.3 - Planification du projet** | 30.5d | 2023-10-09 | 2023-12-18 |  | 0d |
| 17 |  | 1.3.1 - WBS | 11h | 2023-10-09 | 2023-10-20 | 5 |  |
| 18 |  | 1.3.2 - GANTT prévisionnel | 25h | 2023-10-20 | 2023-11-17 | 17 |  |
| 19 |  | 1.3.3 - PERT | 25h | 2023-11-20 | 2023-12-18 | 18 |  |
| 20 | 1.1.4 | **1.4 - Suivi de projet** | 92h | 2023-10-30 | 2024-02-14 |  |  |
| 21 |  | 1.4.1 - Indicateurs de suivi de projet | 8h | 2023-12-18 | 2023-12-27 | 19 |  |
| 22 |  | 1.4.2 - Préparation des vidéos | 8h | 2024-01-10 | 2024-01-19 | 23 |  |
| 23 |  | 1.4.3 - Préparation des rapports glopbaux | 20h | 2023-10-30 | 2023-11-22 | 58 |  |
| 24 |  | 1.4.4 - Préparation oral 1 | 23h | 2023-12-27 | 2024-01-22 | 21 |  |
| 25 |  | 1.4.5 - Préparation oral 2 | 23h | 2024-01-24 | 2024-02-19 | 24 |  |
| 26 |  | 1.4.6 - GANTT réel | 10h | 2024-08-16 | 2024-08-28 | 58 |  |
| 27 | 1.2 | **2 - Développement** | 509h | 2023-09-15 | 2025-04-30 |  |  |
| 28 | 1.2.1 | **2.1 - Conception** | 133h | 2023-09-15 | 2024-02-16 |  |  |
| 29 |  | 2.1.1 - Communication (reseaux) | 15h | 2023-12-11 | 2023-12-27 | 30 |  |
| 30 |  | 2.1.2 - Architecture | 35h | 2023-10-30 | 2023-12-08 | 31 |  |
| 31 |  | 2.1.3 - Diagramme de classes | 30h | 2023-09-25 | 2023-10-30 | 33 |  |
| 32 |  | 2.1.4 - Maquettes | 40h | 2023-10-09 | 2023-11-22 | 5 |  |
| 33 |  | 2.1.5 - MCD & MLD | 10h | 2023-11-24 | 2023-12-04 | 32 |  |
| 34 |  | 2.1.6 - Diagramme de cas d'utilisation | 3h | 2023-09-15 | 2023-09-18 | 10 |  |
| 35 | 1.2.2 | **2.2 - Client Web et Mobile** | 100h | 2023-12-11 | 2024-04-03 |  |  |
| 36 |  | 2.2.1 - Interface utilisateur client (Vues) | 20h | 2023-12-11 | 2024-01-01 | 30 |  |
| 37 |  | 2.2.2 - Gestion des données client | 15h | 2023-12-11 | 2023-12-27 | 30 |  |
| 38 |  | 2.2.3 - Authentification Web et Mobile client | 15h | 2023-12-27 | 2024-01-12 | 29, 37 |  |
| 39 |  | 2.2.4 - Récupération des données de fréquence cardiaque | 10h | 2023-12-11 | 2023-12-20 | 30 |  |
| 40 |  | 2.2.5 - Définitions des algoritmes d'analyse de la fréquence cardiaque | 40h | 2023-12-22 | 2024-02-05 | 39 |  |
| 41 | 1.2.3 | **2.3 - Web admin et monitorin** | 35h | 2023-12-11 | 2024-01-19 |  |  |
| 42 |  | 2.3.1 - Authentification admin et monitoring | 15h | 2023-12-27 | 2024-01-12 | 29 |  |
| 43 |  | 2.3.2 - Interface utilisateur admin (Vues) | 20h | 2023-12-11 | 2024-01-01 | 30 |  |
| 44 | 1.2.4 | **2.4 - Base de données** | 46h | 2023-12-27 | 2024-02-19 |  |  |
| 45 |  | 2.4.1 - Création des tables | 2h | 2023-12-27 | 2023-12-29 | 37 |  |
| 46 |  | 2.4.2 - Ajout des données | 15h | 2023-12-29 | 2024-01-15 | 45 |  |
| 47 |  | 2.4.3 - Mise en place d'un système de backup | 15h | 2023-12-29 | 2024-01-15 | 45 |  |
| 48 |  | 2.4.4 - Création des fonctions | 10h | 2023-12-29 | 2024-01-10 | 45 |  |
| 49 |  | 2.4.5 - Création des index | 4h | 2024-01-17 | 2024-01-19 | 46, 47 |  |
| 50 | 1.2.5 | **2.5 - Serveur et comùmunication de services** | 60h | 2023-12-11 | 2024-02-16 |  |  |
| 51 |  | 2.5.1 - Authentification serveur | 5h | 2023-12-27 | 2024-01-01 | 29 |  |
| 52 |  | 2.5.2 - Stockage cloud | 20h | 2024-01-03 | 2024-01-24 | 51, 53 |  |
| 53 |  | 2.5.3 - Routage | 20h | 2023-12-11 | 2024-01-01 | 30 |  |
| 54 |  | 2.5.4 - Gestion des données serveur | 15h | 2024-01-26 | 2024-02-12 | 52 |  |
| 55 | 1.2.6 | **2.6 - Integration continue et livraison continue (CI/ CD)** | 135h | 2023-12-11 | 2024-05-15 |  |  |
| 56 |  | 2.6.1 - Tests | 175h | 2023-12-11 | 2024-07-01 | 30 |  |
| 57 |  | 2.6.2 - Conteneurisation et déploiement | 20h | 2023-12-11 | 2024-01-01 | 30 |  |
| 58 |  | 2.6.3 - Documentations (swagger, schéma, …) | 40h | 2024-07-01 | 2024-08-16 | 56 |  |

## Version 2 (saved 2023-11-30, file GANTTReel.mpp)

Last finish 2026-01-14 → 2024-01-05 (-740d). Complete tasks 0 → 29.

Added:

| ID | Task | Duration | Start | Finish | Predecessors | Resources |
| --- | --- | --- | --- | --- | --- | --- |
| 8 | 1.1.5 - Compte Rendu (V2) | 7h | 2023-10-03 A | 2023-10-06 A | 5 | Antoine PEREDERII |
| 9 | 1.1.6 - Compte rendu 2 (V2) | 5h | 2023-10-06 A | 2023-10-10 A | 6 | Antoine PEREDERII |
| 10 | 1.1.7 - Rapport BDD | 2h | 2023-11-07 A | 2023-11-07 A | 37 | Antoine PEREDERII; Paul LEVRAULT; David D'ALMEIDA; Kevin MONTEIRO; Antoine PINAGOT |
| 30 | 1.4.7 - Graphe de compétence | 0.5h | 2023-09-20 A | 2023-09-20 A |  | Kevin MONTEIRO |
| 39 | 2.1.7 - Charte graphique | 16h | 2023-10-10 A | 2023-10-20 | 9 | Antoine PINAGOT |
| 40 | 2.1.8 - Logo | 1h | 2023-10-20 A | 2023-10-20 A |  | David D'ALMEIDA |
| 47 | 2.2.6 - Mise en place Bootstrap | 3.6h | 2023-10-28 A | 2023-11-03 | 34, 38 | Antoine PINAGOT |
| 48 | 2.2.7 - Mise en place talwind | 1.5h | 2023-10-28 A | 2023-10-30 A | 34, 38 | Antoine PINAGOT |
| 49 | 2.2.8 - Mise en place lead PHPStorm | 1h | 2023-10-28 A | 2023-10-30 A | 34, 38 | David D'ALMEIDA |
| 68 | **2.7 Configuration** | 11d? | 2023-10-06 A | 2023-10-20 A |  |  |
| 69 | 2.6.1 - Installation Twig | 0.5h | 2023-10-06 A | 2023-10-06 A | 34 | Antoine PINAGOT |
| 70 | 2.6.2 - Bootstrap | 2h | 2023-10-06 A | 2023-10-06 A | 34 | Antoine PINAGOT |
| 71 | 2.6.3 - PHP Unite | 10h | 2023-10-11 A | 2023-10-16 A | 43 | David D'ALMEIDA; Paul LEVRAULT |
| 72 | 2.6.4 - Node | 10h | 2023-10-11 A | 2023-10-16 A | 43 | Antoine PINAGOT |
| 73 | 2.6.5 - Autoloader | 2h | 2023-10-06 A | 2023-10-06 A | 34 | Antoine PINAGOT |
| 74 | 2.6.6 - Composer | 2h | 2023-10-06 A | 2023-10-06 A | 34 | Antoine PINAGOT; David D'ALMEIDA |
| 75 | 2.6.7 - Architecture Repository | 30h? | 2023-10-06 A | 2023-10-20 A | 34 | Antoine PINAGOT; Kevin MONTEIRO |

Changed:

| ID | Task | Start | Finish | Duration | Complete | Total float | Predecessors | Other |
| --- | --- | --- | --- | --- | --- | --- | --- | --- |
| 1 | **Étude de courbes de fréquence cardiaque** | 2023-09-15 → 2023-09-14 A (-1d) | 2026-01-14 → 2024-01-05 (-740d) | 733h → 80.64d? | 0% → 48% | none → 0d |  |  |
| 2 | **1 - Management de projet** | 2023-09-15 → 2023-09-14 A (-1d) | 2024-05-31 → 2023-11-30 (-183d) | 224h → 54.78d | 0% → 86% | none → 25.85d |  |  |
| 3 | **1.1 - Recueil de besoins** | 2023-09-15 → 2023-09-14 A (-1d) | 2023-11-08 → 2023-11-07 (-1d) | 49h → 38.5d | 0% → 93% | none → 42.13d |  |  |
| 4 | 1.1.1 - Présentation general du projet | 2023-09-15 → 2023-09-18 A (+3d) | 2023-09-20 → 2023-09-18 A (-2d) | 5h → 2h | 0% → 100% |  |  |  |
| 5 | 1.1.2 - Compte rendu 1 | 2023-09-20 → 2023-09-22 A (+2d) | 2023-09-29 → 2023-09-22 A (-7d) | 9h → 3h | 0% → 100% |  |  |  |
| 6 | 1.1.3 - Compte rendu 2 | 2023-10-04 → 2023-10-05 A (+1d) | 2023-10-06 A | 4h → 5h | 0% → 100% |  |  |  |
| 7 | 1.1.4 - Backlog (users stories) | 2023-10-06 → 2023-10-02 A (-4d) | 2023-10-06 → 2023-10-04 A (-2d) | 0h → 5h | 0% → 100% |  |  | resources Antoine PEREDERII; David D'ALMEIDA; Kevin MONTEIRO → David D'ALMEIDA; Paul LEVRAULT |
| 11 | **1.1.5 - Rendez vous** | 2023-09-15 → 2023-09-14 A (-1d) | 2023-09-15 → 2023-09-20 (+5d) | 2h → 4d | 0% → 64% | none → 76.64d |  |  |
| 12 | 1.1.5.1 - Avec le tuteur | 2023-09-15 → 2023-09-18 A (+3d) | 2023-09-15 → 2023-09-20 (+5d) | 1h → 4h | 0% → 88% | none → 76.64d |  |  |
| 13 | 1.1.5.2 - Avec le client | 2023-09-15 → 2023-09-14 (-1d) |  | 1h → 3h | 0% → 33% | none → 24d |  |  |
| 14 | **1.2 - Organisation du travail en équipe** | 2023-09-15 A | 2023-10-09 → 2023-09-28 A (-11d) | 22h → 10d | 0% → 100% |  |  |  |
| 15 | 1.2.1 - Mise en place du kanban | 2023-09-15 A | 2023-09-15 → 2023-09-28 A (+13d) |  | 0% → 100% |  |  |  |
| 16 | 1.2.2 - Mise en place du codefirst | 2023-09-15 → 2023-09-25 A (+10d) | 2023-10-02 → 2023-09-26 A (-6d) | 15h → 3h | 0% → 100% |  |  |  |
| 17 | 1.2.3 - Mise en place du notion | 2023-09-15 A | 2023-09-18 → 2023-09-15 A (-3d) | 3h → 2h | 0% → 100% |  |  | resources David D'ALMEIDA → David D'ALMEIDA; Antoine PEREDERII |
| 18 | 1.2.4 - Mise en place du discord | 2023-09-15 A | 2023-09-15 A | 2h → 0.5h | 0% → 100% |  |  |  |
| 19 | **1.3 - Planification du projet** | 2023-10-09 → 2023-09-20 A (-19d) | 2023-12-18 → 2023-10-12 A (-67d) | 30.5d → 16.5d | 0% → 100% | 0d → none |  |  |
| 20 | 1.3.1 - WBS | 2023-10-09 → 2023-09-20 A (-19d) | 2023-10-20 → 2023-09-22 A (-28d) | 11h → 6h | 0% → 100% |  |  |  |
| 21 | 1.3.2 - GANTT prévisionnel | 2023-10-20 → 2023-09-29 A (-21d) | 2023-11-17 → 2023-10-12 A (-36d) | 25h → 17h | 0% → 100% |  |  |  |
| 22 | 1.3.3 - PERT | 2023-11-20 → 2023-10-09 A (-42d) | 2023-12-18 → 2023-10-11 A (-68d) | 25h → 4h | 0% → 100% |  |  |  |
| 23 | **1.4 - Suivi de projet** | 2023-10-30 → 2023-09-20 A (-40d) | 2024-02-14 → 2023-11-30 (-76d) | 92h → 51.28d | 0% → 46% | none → 25.85d |  |  |
| 24 | 1.4.1 - Indicateurs de suivi de projet | 2023-12-18 → 2023-11-22 A (-26d) | 2023-12-27 → 2023-11-23 (-34d) | 8h → 3h | 0% → 70% | none → 30.14d |  | resources David D'ALMEIDA → David D'ALMEIDA; Antoine PEREDERII |
| 25 | 1.4.2 - Préparation des vidéos | 2024-01-10 → 2023-11-28 (-43d) | 2024-01-19 → 2023-11-30 (-50d) | 8h → 3h |  | none → 25.85d |  |  |
| 26 | 1.4.3 - Préparation des rapports globaux | 2023-10-30 → 2023-11-27 (+28d) | 2023-11-22 → 2023-11-28 (+6d) | 20h → 2h |  | none → 25.85d |  | was named 1.4.3 - Préparation des rapports glopbaux |
| 27 | 1.4.4 - Préparation oral 1 | 2023-12-27 → 2023-11-14 A (-43d) | 2024-01-22 → 2023-11-24 A (-59d) | 23h → 5h | 0% → 100% |  |  |  |
| 28 | 1.4.5 - Préparation oral 2 | 2024-01-24 → 2023-11-27 (-58d) | 2024-02-19 → 2023-11-28 (-83d) | 23h → 3.75h |  | none → 27.26d |  | resources Antoine PEREDERII; Antoine PINAGOT; David D'ALMEIDA; Kevin MONTEIRO; Paul LEVRAULT → Antoine PEREDERII; Antoine PINAGOT; Kevin MONTEIRO; Paul LEVRAULT |
| 29 | 1.4.6 - GANTT réel | 2024-08-16 → 2023-11-14 A (-276d) | 2024-08-28 → 2023-11-28 (-274d) | 10h → 1.5h | 0% → 67% | none → 28.1d |  | resources Antoine PEREDERII; Kevin MONTEIRO → Antoine PINAGOT; Antoine PEREDERII |
| 31 | **2 - Développement** | 2023-09-15 → 2023-09-25 A (+10d) | 2025-04-30 → 2024-01-05 (-481d) | 509h → 73.64d? | 0% → 38% | none → 0d |  |  |
| 32 | **2.1 - Conception** | 2023-09-15 → 2023-09-25 A (+10d) | 2024-02-16 → 2023-11-14 (-94d) | 133h → 36.05d | 0% → 48% | none → 37.58d |  |  |
| 33 | 2.1.1 - Communication (reseaux) | 2023-12-11 → 2023-10-06 A (-66d) | 2023-12-27 → 2023-11-14 (-43d) | 15h → 17.2h | 0% → 7% | none → 0.75d |  |  |
| 34 | 2.1.2 - Architecture | 2023-10-30 → 2023-09-29 A (-31d) | 2023-12-08 → 2023-11-02 (-36d) | 35h → 12h | 0% → 7% | none → 0d |  |  |
| 35 | 2.1.3 - Diagramme de classes | 2023-09-25 A | 2023-10-30 → 2023-10-25 (-5d) | 30h → 11.14h | 0% → 43% | none → 0d |  | resources Antoine PEREDERII; Antoine PINAGOT; David D'ALMEIDA; Kevin MONTEIRO; Paul LEVRAULT → Antoine PEREDERII; Antoine PINAGOT; David D'ALMEIDA |
| 36 | 2.1.4 - Maquettes | 2023-10-09 → 2023-09-28 A (-11d) | 2023-11-22 → 2023-10-04 A (-49d) | 40h → 12h | 0% → 100% |  |  |  |
| 37 | 2.1.5 - MCD & MLD | 2023-11-24 → 2023-10-16 A (-39d) | 2023-12-04 → 2023-10-19 A (-46d) | 10h → 8h | 0% → 100% |  |  | resources David D'ALMEIDA; Paul LEVRAULT → David D'ALMEIDA; Paul LEVRAULT; Kevin MONTEIRO; Antoine PINAGOT; Antoine PEREDERII |
| 38 | 2.1.6 - Diagramme de cas d'utilisation | 2023-09-15 → 2023-10-16 A (+31d) | 2023-09-18 → 2023-10-20 (+32d) | 3h → 10h | 0% → 80% | none → 8.55d |  | resources David D'ALMEIDA; Kevin MONTEIRO → Kevin MONTEIRO; Antoine PEREDERII |
| 41 | **2.2 - Client Web et Mobile** | 2023-12-11 → 2023-10-27 A (-45d) | 2024-04-03 → 2023-12-04 (-121d) | 100h → 26.07d? | 0% → 20% | none → 23.58d |  |  |
| 42 | 2.2.1 - Interface utilisateur client (Vues) | 2023-12-11 → 2023-11-06 A (-35d) | 2024-01-01 → 2023-11-15 (-47d) | 20h → 15h? | 0% → 35% | none → 36.13d |  | resources Antoine PEREDERII; Paul LEVRAULT → Antoine PINAGOT |
| 43 | 2.2.2 - Gestion des données client | 2023-12-11 → 2023-11-02 (-39d) | 2023-12-27 → 2023-12-01 (-26d) | 15h → 41h? |  | none → 23.58d |  |  |
| 44 | 2.2.3 - Authentification Web et Mobile client | 2023-12-27 → 2023-12-01 (-26d) | 2024-01-12 → 2023-12-04 (-39d) | 15h → 1.5h |  | none → 23.58d | 33, 43 → 33, 43, 47, 48, 49, 69, 70, 71, 72, 73, 74, 75 | resources Antoine PINAGOT; Kevin MONTEIRO → Antoine PINAGOT; Kevin MONTEIRO; David D'ALMEIDA |
| 45 | 2.2.4 - Récupération des données de fréquence cardiaque | 2023-12-11 → 2023-10-27 A (-45d) | 2023-12-20 → 2023-11-03 (-47d) | 10h → 5h | 0% → 80% | none → 45.08d |  |  |
| 46 | 2.2.5 - Définitions des algoritmes d'analyse de la fréquence cardiaque | 2023-12-22 → 2023-11-14 (-38d) | 2024-02-05 → 2023-11-21 (-76d) | 40h → 0h |  | none → 32.58d | 45 → 33 | resources David D'ALMEIDA; Kevin MONTEIRO → David D'ALMEIDA |
| 50 | **2.3 - Web admin et monitorin** | 2023-12-11 → 2023-11-02 (-39d) | 2024-01-19 → 2023-11-20 (-60d) | 35h → 11.75d |  | none → 33.83d |  |  |
| 51 | 2.3.1 - Authentification admin et monitoring | 2023-12-27 → 2023-11-14 (-43d) | 2024-01-12 → 2023-11-20 (-53d) | 15h → 7.5h |  | none → 33.83d |  | resources David D'ALMEIDA; Kevin MONTEIRO; Paul LEVRAULT → Antoine PEREDERII; Antoine PINAGOT |
| 52 | 2.3.2 - Interface utilisateur admin (Vues) | 2023-12-11 → 2023-11-02 (-39d) | 2024-01-01 → 2023-11-09 (-53d) | 20h → 10h |  | none → 40.58d |  | resources Kevin MONTEIRO → Antoine PINAGOT |
| 53 | **2.4 - Base de données** | 2023-12-27 → 2023-10-20 A (-68d) | 2024-02-19 → 2023-12-13 (-68d) | 46h → 38.5d | 0% → 15% | none → 16.64d |  |  |
| 54 | 2.4.1 - Création des tables | 2023-12-27 → 2023-10-20 A (-68d) | 2023-12-29 → 2023-10-20 A (-70d) |  | 0% → 100% |  |  |  |
| 55 | 2.4.2 - Ajout des données | 2023-12-29 → 2023-10-20 A (-70d) | 2024-01-15 → 2023-10-23 (-84d) | 15h → 2.17h | 0% → 21% | none → 52.27d |  | resources Antoine PINAGOT → Antoine PINAGOT; Antoine PEREDERII |
| 56 | 2.4.3 - Mise en place d'un système de backup | 2023-12-29 → 2023-10-23 (-67d) | 2024-01-15 → 2023-12-12 (-34d) | 15h → 6h |  | none → 16.64d |  | resources Antoine PEREDERII; David D'ALMEIDA; Kevin MONTEIRO → Antoine PEREDERII; David D'ALMEIDA |
| 57 | 2.4.4 - Création des fonctions | 2023-12-29 → 2023-10-23 (-67d) | 2024-01-10 → 2023-10-24 (-78d) | 10h → 4h |  | none → 52.13d |  | resources David D'ALMEIDA → Antoine PINAGOT |
| 58 | 2.4.5 - Création des index | 2024-01-17 → 2023-12-12 (-36d) | 2024-01-19 → 2023-12-13 (-37d) | 4h → 2h |  | none → 16.64d |  | resources Antoine PEREDERII → Antoine PEREDERII; David D'ALMEIDA |
| 59 | **2.5 - Serveur et comùmunication de services** | 2023-12-11 → 2023-11-02 (-39d) | 2024-02-16 → 2024-01-05 (-42d) | 60h → 45.58d |  | none → 0d |  |  |
| 60 | 2.5.1 - Authentification serveur | 2023-12-27 → 2023-11-14 (-43d) | 2024-01-01 → 2023-12-29 (-3d) | 5h → 4h |  | none → 0.75d |  |  |
| 61 | 2.5.2 - Stockage cloud | 2024-01-03 → 2023-12-29 (-5d) | 2024-01-24 → 2024-01-02 (-22d) | 20h → 3.33h |  | none → 0d |  | resources David D'ALMEIDA → David D'ALMEIDA; Antoine PEREDERII; Antoine PINAGOT |
| 62 | 2.5.3 - Routage | 2023-12-11 → 2023-11-02 (-39d) | 2024-01-01 → 2023-12-29 (-3d) | 20h → 18h |  | none → 0d |  |  |
| 63 | 2.5.4 - Gestion des données serveur | 2024-01-26 → 2024-01-02 (-24d) | 2024-02-12 → 2024-01-05 (-38d) | 15h → 5.33h |  | none → 0d |  | resources Kevin MONTEIRO; Antoine PINAGOT → Antoine PINAGOT; Antoine PEREDERII; David D'ALMEIDA |
| 64 | **2.6 - Integration continue et livraison continue (CI/ CD)** | 2023-12-11 → 2023-10-27 A (-45d) | 2024-05-15 → 2023-12-06 (-161d) | 135h → 28d | 0% → 19% | none → 21.66d |  |  |
| 65 | 2.6.1 - Tests | 2023-12-11 → 2023-10-27 A (-45d) | 2024-07-01 → 2023-11-22 (-222d) | 175h → 35h | 0% → 20% | none → 0d |  |  |
| 66 | 2.6.2 - Conteneurisation et déploiement | 2023-12-11 → 2023-10-27 A (-45d) | 2024-01-01 → 2023-12-06 (-26d) | 20h → 8h | 0% → 30% | none → 21.66d |  |  |
| 67 | 2.6.3 - Documentations (swagger, schéma, …) | 2024-07-01 → 2023-11-15 A (-229d) | 2024-08-16 → 2023-11-27 (-263d) | 40h → 6.67h | 0% → 3% | none → 0d |  | resources Antoine PEREDERII; Antoine PINAGOT; David D'ALMEIDA; Kevin MONTEIRO; Paul LEVRAULT → Antoine PEREDERII; Antoine PINAGOT; David D'ALMEIDA |
